# Libra Training Manual

Schedule from MS Project, 2005-08-01 to 2005-10-10, costs in $.
Coleman Publishing
Our goal is to be first to market with a quality product!

## Calendars

- COLEMAN: Mon-Fri 08:00-12:00, 13:00-17:00; Sat-Sun off. Exceptions (off unless hours are given): 2005-09-05.

## Resources

| Resource | Group | Rate | Notes |
| --- | --- | --- | --- |
| Writer 1 | Internal | 45 |  |
| Editor 1 | Internal | 17 |  |
| Printer 1 | Internal | 10 |  |
| Artist 1 | Internal | 25 |  |
| Project Manager 1 | Internal | 60 |  |
| Staff Assistant 1 | Internal | 12 |  |
| Staff Assistant 2 | Internal | 12 | Given enough notice, this resource can work afternoons instead of mornings. |
| Account Rep 1 | Internal | 20 |  |
| Publisher 1 | Internal | 48.08 |  |
| Subject Matter Expert | External | 100 |  |
| Glossy Paper | External | 150 |  |
| Plain Paper |  | 45 |  |

## Schedule

| ID | WBS | Task | Type | Duration | Start | Finish | Predecessors | Total slack | Free slack | Constraint | Resources | Work | Cost |
| --- | --- | --- | --- | --- | --- | --- | --- | --- | --- | --- | --- | --- | --- |
| 1 | 1 | Start Book | milestone | 0d | 2005-08-01 | 2005-08-01 |  | 49.33d |  |  |  |  |  |
| 2 | 2 | **Research Phase** |  | 8d | 2005-08-01 | 2005-08-10 |  | 3d |  |  |  | 88h | 3,936 |
| 3 | 2.1 | Interview Subject Matter Experts |  | 2d | 2005-08-01 | 2005-08-02 |  | 3d | 0d |  | Writer 1; Project Manager 1 | 32h | 1,680 |
| 4 | 2.2 | Investigate the software |  | 5d | 2005-08-03 | 2005-08-09 | 3 | 3d | 0d |  | Writer 1 | 40h | 1,800 |
| 5 | 2.3 | Search the Web |  | 1d | 2005-08-10 | 2005-08-10 | 4 | 3d | 0d |  | Writer 1; Staff Assistant 1 | 16h | 456 |
| 6 | 3 | **Outline Phase** |  | 7.5d | 2005-08-11 | 2005-08-22 |  | 0d |  |  |  | 44h | 2,216.92 |
| 7 | 3.1 | Create outline |  | 3d | 2005-08-11 | 2005-08-15 | 5 | 3d | 0d |  | Writer 1 | 24h | 1,080 |
| 8 | 3.2 | Present to publisher |  | 0.2d | 2005-08-16 | 2005-08-16 | 7 | 3d |  |  | Project Manager 1 [50%]; Writer 1; Publisher 1 | 4h | 196.92 |
| 9 | 3.3 | Review with Subject Matter Expert |  | 0.5d | 2005-08-19 | 2005-08-19 | 8SS | 0d |  | start no earlier than 2005-08-19 | Writer 1; Subject Matter Expert | 8h | 580 |
| 10 | 3.4 | Revise outline |  | 1d | 2005-08-19 | 2005-08-22 | 9 | 0d |  |  | Writer 1 | 8h | 360 |
| 11 | 4 | **Development Phase** |  | 27.5d | 2005-08-22 | 2005-09-29 |  | 0d |  |  |  | 240h | 9,740 |
| 12 | 4.1 | Write content |  | 25d | 2005-08-22 | 2005-09-27 | 10 | 0d |  |  | Writer 1 | 200h | 9,000 |
| 13 | 4.2 | Add graphics |  | 2.5d | 2005-09-27 | 2005-09-29 | 12 | 0d |  |  | Artist 1; Staff Assistant 1 | 40h | 740 |
| 14 | 5 | **Edit Phase** |  | 3d | 2005-09-30 | 2005-10-04 |  | 0d |  |  |  | 40h | 1,344 |
| 15 | 5.1 | Check grammar, spelling, and proofread |  | 3d | 2005-09-30 | 2005-10-04 | 13 | 0d |  |  | Editor 1 | 24h | 408 |
| 16 | 5.2 | Check for technical accuracy |  | 1d | 2005-10-04 | 2005-10-04 | 15FF | 0d |  |  | Editor 1; Subject Matter Expert | 16h | 936 |
| 17 | 6 | **Review Phase** |  | 1.5d | 2005-10-05 | 2005-10-06 |  | 0d |  |  |  | 16h | 608 |
| 18 | 6.1 | Approve editing changes |  | 1d | 2005-10-05 | 2005-10-05 | 16 | 0d |  |  | Writer 1 | 8h | 360 |
| 19 | 6.2 | Meet with editor |  | 0.5d | 2005-10-06 | 2005-10-06 | 18 | 0d |  |  | Writer 1; Editor 1 | 8h | 248 |
| 20 | 7 | **Print Phase** |  | 1.83d | 2005-10-06 | 2005-10-10 |  | 0d |  |  |  | 24h | 775.33 |
| 21 | 7.1 | Print proof |  | 0.5d | 2005-10-06 | 2005-10-06 | 19 | 0d |  |  | Printer 1; Plain Paper | 8h | 220 |
| 22 | 7.2 | Review proof |  | 0.33d | 2005-10-07 | 2005-10-07 | 21 | 0d |  |  | Writer 1; Editor 1; Project Manager 1 | 8h | 325.33 |
| 23 | 7.3 | Print final |  | 1d | 2005-10-07 | 2005-10-10 | 22 | 0d |  |  | Printer 1; Glossy Paper | 8h | 230 |
| 24 | 8 | Book Complete | milestone | 0d | 2005-10-10 | 2005-10-10 | 23 | 0d |  |  |  |  |  |

Notes:
- 7: Post Outline.doc to the Marketing Web Page.
- 13: Post a Course.xml to the Content Mangement System.
- 21: Provide a hard copy proof to Project Manager.
