# CSS Training Manual

Schedule from MS Project, 2005-08-01 to 2005-09-28, costs in $.
Book development
Coleman Publishing
Office Manager on vacation 9/2/05.

## Calendars

- COLEMAN: Mon-Fri 08:00-12:00, 13:00-17:00; Sat-Sun off. Exceptions (off unless hours are given): 2005-09-05.

## Resources

| Resource | Group | Rate | Cost per use |
| --- | --- | --- | --- |
| Editor 1 | Internal | 17 |  |
| Printer 1 | External | 8 |  |
| Publisher 1 | Internal | 48.08 |  |
| Staff Assistant 1 | Internal | 10 |  |
| Staff Assistant 2 | Internal | 10 |  |
| Subject Matter Expert 1 | External | 30 |  |
| Subject Matter Expert 2 | External | 30 |  |
| Writer 1 | Internal | 45 |  |
| Account Rep 1 | External |  | 500 |
| Glossy paper | External | 150 |  |
| Artist 1 | External |  | 625 |

## Schedule

| ID | WBS | Task | Type | Duration | Start | Finish | Predecessors | Baseline start | Baseline finish | Baseline duration | Total slack | Free slack | Constraint | Resources | Work | Cost | Baseline cost |
| --- | --- | --- | --- | --- | --- | --- | --- | --- | --- | --- | --- | --- | --- | --- | --- | --- | --- |
| 1 | 1 | Start Book | milestone | 0d | 2005-08-01 | 2005-08-01 |  | 2005-08-01 | 2005-08-01 | 0d | 0d |  |  |  |  |  |  |
| 2 | 2 | **Research Phase** |  | 4.12d | 2005-08-01 | 2005-08-05 |  | 2005-08-01 | 2005-08-05 | 4.12d | 0d |  |  |  | 64h | 1,760 | 1,760 |
| 3 | 2.1 | Interview Subject Matter Experts |  | 2d | 2005-08-01 | 2005-08-02 | 1 | 2005-08-01 | 2005-08-04 | 2d | 0d |  |  | Writer 1 | 16h | 720 | 720 |
| 4 | 2.2 | Search the Web |  | 3.25d | 2005-08-01 | 2005-08-05 | 3SS+2% | 2005-08-01 | 2005-08-05 | 3.25d | 0d |  |  | Staff Assistant 1; Staff Assistant 2; Writer 1 | 48h | 1,040 | 1,040 |
| 5 | 3 | **Outline Phase** |  | 7d | 2005-08-05 | 2005-08-16 |  | 2005-08-05 | 2005-08-16 | 7d | 0d |  |  |  | 64h | 2,492.3 | 2,492.3 |
| 6 | 3.1 | Create outline |  | 5d | 2005-08-05 | 2005-08-12 | 4 | 2005-08-05 | 2005-08-12 | 5d | 0d |  |  | Writer 1 | 40h | 1,800 | 1,800 |
| 7 | 3.2 | Present to publisher |  | 0.5d | 2005-08-12 | 2005-08-12 | 6 | 2005-08-12 | 2005-08-12 | 0.5d | 0d |  |  | Writer 1; Publisher 1 | 8h | 372.3 | 372.3 |
| 8 | 3.3 | Revise Outline |  | 1d | 2005-08-12 | 2005-08-15 | 7 | 2005-08-12 | 2005-08-15 | 1d | 0d |  |  | Staff Assistant 1 | 8h | 80 | 80 |
| 9 | 3.4 | Review with Subject Matter Expert |  | 0.5d | 2005-08-15 | 2005-08-16 | 8 | 2005-08-15 | 2005-08-16 | 0.5d | 18.5d | 0d |  | Subject Matter Expert 1; Subject Matter Expert 2 | 8h | 240 | 240 |
| 10 | 3.5 | Outline complete | milestone | 0d | 2005-08-16 | 2005-08-16 | 9 | 2005-08-16 | 2005-08-16 | 0d | 18.5d |  |  |  |  |  |  |
| 11 | 4 | **Development Phase** |  | 20d | 2005-08-15 | 2005-09-13 |  | 2005-08-15 | 2005-09-13 | 21d | 0d |  |  |  | 200h | 7,825 | 7,825 |
| 12 | 4.1 | Write content |  | 20d | 2005-08-15 | 2005-09-12 | 10FF, 8 | 2005-08-15 | 2005-09-12 | 20d | 0d |  |  | Writer 1 | 160h | 7,200 | 7,200 |
| 13 | 4.2 | Add graphics |  | 1w | 2005-09-06 | 2005-09-13 | 12FF+1d | 2005-09-06 | 2005-09-13 | 1w | 0d |  |  | Artist 1 | 40h | 625 | 625 |
| 14 | 4.3 | Development complete | milestone | 0d | 2005-09-13 | 2005-09-13 | 13 | 2005-09-13 | 2005-09-13 | 0d | 0d |  |  |  |  |  |  |
| 15 | 5 | **Edit Phase** |  | 5d | 2005-09-13 | 2005-09-20 |  | 2005-09-13 | 2005-09-20 | 5d | 0d |  |  |  | 90h | 2,570 | 2,570 |
| 16 | 5.1 | Check grammar, spelling, and proofread |  | 1w | 2005-09-13 | 2005-09-20 | 14 | 2005-09-13 | 2005-09-20 | 1w | 0d |  | start no earlier than 2005-09-13 | Editor 1 [25%] | 10h | 170 | 170 |
| 17 | 5.2 | Check for technical accuracy |  | 1w | 2005-09-13 | 2005-09-20 | 16FF | 2005-09-13 | 2005-09-20 | 1w | 0d |  |  | Subject Matter Expert 1; Subject Matter Expert 2 | 80h | 2,400 | 2,400 |
| 18 | 6 | **Review Phase** |  | 1.25d | 2005-09-20 | 2005-09-21 |  | 2005-09-20 | 2005-09-21 | 1.25d | 0d |  |  |  | 20h | 564 | 564 |
| 19 | 6.1 | Approve editing changes |  | 1d | 2005-09-20 | 2005-09-21 | 17 | 2005-09-20 | 2005-09-21 | 1d | 0d |  |  | Writer 1; Staff Assistant 2 | 16h | 440 | 440 |
| 20 | 6.2 | Meet with editor |  | 0.25d | 2005-09-21 | 2005-09-21 | 19 | 2005-09-21 | 2005-09-21 | 0.25d | 0d |  |  | Writer 1; Editor 1 | 4h | 124 | 124 |
| 21 | 7 | **Print Phase** |  | 5d | 2005-09-21 | 2005-09-28 |  | 2005-09-21 | 2005-09-28 | 5d | 0d |  |  |  | 64h | 1,598 | 1,598 |
| 22 | 7.1 | Print proof |  | 1d | 2005-09-21 | 2005-09-22 | 20 | 2005-09-21 | 2005-09-22 | 1d | 0d |  |  | Printer 1 | 8h | 64 | 64 |
| 23 | 7.2 | Review proof |  | 3d | 2005-09-22 | 2005-09-27 | 22 | 2005-09-22 | 2005-09-27 | 3d | 0d |  |  | Writer 1; Staff Assistant 1 | 48h | 1,320 | 1,320 |
| 24 | 7.3 | Print final |  | 1d | 2005-09-27 | 2005-09-28 | 23 | 2005-09-27 | 2005-09-28 | 1d | 0d |  |  | Printer 1 | 8h | 214 | 214 |
| 25 | 8 | Book Complete | milestone | 0d | 2005-09-28 | 2005-09-28 | 24 | 2005-09-28 | 2005-09-28 | 0d | 0.12d |  | finish no later than 2005-09-28 |  |  |  |  |

Notes:
- 24: $150 for special paper.
- 25: CEO requires completion by 9/28/05.
