# CSS Training Manual

Schedule from MS Project, 2005-08-01 to 2005-10-19, costs in $.
Cascading Style Sheets
Coleman Publishing
Our goal is to be first to market with a quality product!

## Calendars

- COLEMAN: Mon-Fri 08:00-12:00, 13:00-17:00; Sat-Sun off. Exceptions (off unless hours are given): 2005-09-05.

## Resources

| Resource | Group | Rate | Notes |
| --- | --- | --- | --- |
| Writer 1 |  | 45 | Software expert. |
| Editor 1 |  | 17 | Style expert. |
| Printer 1 |  | 10 | Needs setup time. |
| Artist 1 |  | 25 | Callouts, custom figures. |
| Project Manager 1 |  | 60 | Specializes in short projects. |
| Staff Assistant 1 |  | 12 | Competent under pressure. |
| Account Rep 1 |  | 20 | Very creative. |
| Publisher 1 |  | 48.08 | Lots of patience. |
| Subject Matter Expert 1 |  | 100 | From TC Agency. |
| Glossy paper | External | 150 | For final printing. |
| Plain paper |  | 75 | For printing the proof. |

## Schedule

| ID | WBS | Task | Type | Duration | Start | Finish | Predecessors | Baseline start | Baseline finish | Baseline duration | Total slack | Free slack | Constraint | Resources | Work | Cost | Baseline cost |
| --- | --- | --- | --- | --- | --- | --- | --- | --- | --- | --- | --- | --- | --- | --- | --- | --- | --- |
| 1 | 1 | Start Book | milestone | 0d | 2005-08-01 | 2005-08-01 |  | 2005-08-01 | 2005-08-01 | 0d | 57d |  |  | Project Manager 1; Writer 1 |  |  |  |
| 2 | 2 | **Research Phase** |  | 8d | 2005-08-01 | 2005-08-10 |  | 2005-08-01 | 2005-08-10 | 8d | 3d |  |  |  | 112h | 5,632 | 5,632 |
| 3 | 2.1 | Interview Subject Matter Expert |  | 2d | 2005-08-01 | 2005-08-02 |  | 2005-08-01 | 2005-08-02 | 2d | 3d | 0d |  | Project Manager 1; Writer 1; Subject Matter Expert 1 | 48h | 3,280 | 3,280 |
| 4 | 2.2 | Investigate the software |  | 4d | 2005-08-03 | 2005-08-08 | 3 | 2005-08-03 | 2005-08-08 | 4d | 3d | 0d |  | Writer 1 | 32h | 1,440 | 1,440 |
| 5 | 2.3 | Search the Web |  | 2d | 2005-08-09 | 2005-08-10 | 4 | 2005-08-09 | 2005-08-10 | 2d | 3d | 0d |  | Writer 1; Staff Assistant 1 | 32h | 912 | 912 |
| 6 | 3 | **Outline Phase** |  | 9d | 2005-08-11 | 2005-08-23 |  | 2005-08-11 | 2005-08-23 | 9d | 0d |  |  |  | 88h | 4,984.61 | 4,984.61 |
| 7 | 3.1 | Create outline |  | 3d | 2005-08-11 | 2005-08-15 | 5 | 2005-08-11 | 2005-08-15 | 3d | 3d | 0d |  | Writer 1 | 24h | 1,080 | 1,080 |
| 8 | 3.2 | Present to publisher |  | 1d | 2005-08-16 | 2005-08-16 | 7 | 2005-08-16 | 2005-08-16 | 1d | 3d |  |  | Writer 1; Project Manager 1; Publisher 1 | 24h | 1,224.61 | 1,224.61 |
| 9 | 3.3 | Review with Subject Matter Expert |  | 2d | 2005-08-19 | 2005-08-22 | 8SS | 2005-08-19 | 2005-08-22 | 2d | 0d |  | start no earlier than 2005-08-19 | Writer 1; Subject Matter Expert 1 | 32h | 2,320 | 2,320 |
| 10 | 3.4 | Revise outline |  | 1d | 2005-08-23 | 2005-08-23 | 9 | 2005-08-23 | 2005-08-23 | 1d | 0d |  |  | Writer 1 | 8h | 360 | 360 |
| 11 | 4 | **Development Phase** |  | 30d | 2005-08-24 | 2005-10-05 |  | 2005-08-24 | 2005-10-05 | 30d | 0d |  |  |  | 280h | 10,480 | 10,480 |
| 12 | 4.1 | Write content |  | 25d | 2005-08-24 | 2005-09-28 | 10 | 2005-08-24 | 2005-09-28 | 25d | 0d |  |  | Writer 1 | 200h | 9,000 | 9,000 |
| 13 | 4.2 | Add graphics |  | 5d | 2005-09-29 | 2005-10-05 | 12 | 2005-09-29 | 2005-10-05 | 5d | 0d |  |  | Artist 1; Staff Assistant 1 | 80h | 1,480 | 1,480 |
| 14 | 5 | **Edit Phase** |  | 5d | 2005-10-06 | 2005-10-12 |  | 2005-10-06 | 2005-10-12 | 5d | 0d |  |  |  | 56h | 2,280 | 2,280 |
| 15 | 5.1 | Check grammar, spelling, and proofread |  | 3d | 2005-10-06 | 2005-10-10 | 13 | 2005-10-06 | 2005-10-10 | 3d | 0d |  |  | Editor 1 | 24h | 408 | 408 |
| 16 | 5.2 | Check for technical accuracy |  | 2d | 2005-10-11 | 2005-10-12 | 15FF | 2005-10-11 | 2005-10-12 | 2d | 0d |  |  | Editor 1; Subject Matter Expert 1 | 32h | 1,872 | 1,872 |
| 17 | 6 | **Review Phase** |  | 2d | 2005-10-13 | 2005-10-14 |  | 2005-10-13 | 2005-10-14 | 2d | 0d |  |  |  | 24h | 856 | 856 |
| 18 | 6.1 | Approve editing changes |  | 1d | 2005-10-13 | 2005-10-13 | 16 | 2005-10-13 | 2005-10-13 | 1d | 0d |  |  | Writer 1 | 8h | 360 | 360 |
| 19 | 6.2 | Meet with editor |  | 1d | 2005-10-14 | 2005-10-14 | 18 | 2005-10-14 | 2005-10-14 | 1d | 0d |  |  | Writer 1; Editor 1 | 16h | 496 | 496 |
| 20 | 7 | **Print Phase** |  | 3d | 2005-10-17 | 2005-10-19 |  | 2005-10-17 | 2005-10-19 | 3d | 0d |  |  |  | 40h | 1,361 | 1,436 |
| 21 | 7.1 | Print proof |  | 1d | 2005-10-17 | 2005-10-17 | 19 | 2005-10-17 | 2005-10-17 | 1d | 0d |  |  | Printer 1; Plain paper | 8h | 155 | 230 |
| 22 | 7.2 | Review proof |  | 1d | 2005-10-18 | 2005-10-18 | 21 | 2005-10-18 | 2005-10-18 | 1d | 0d |  |  | Writer 1; Editor 1; Project Manager 1 | 24h | 976 | 976 |
| 23 | 7.3 | Print final |  | 1d | 2005-10-19 | 2005-10-19 | 22 | 2005-10-19 | 2005-10-19 | 1d | 0d |  |  | Printer 1; Glossy paper | 8h | 230 | 230 |
| 24 | 8 | Book Complete | milestone | 0d | 2005-10-19 | 2005-10-19 | 23 | 2005-10-19 | 2005-10-19 | 0d | 0d |  |  | Project Manager 1; Writer 1 |  |  |  |

Notes:
- 7: Send CSS Outline.doc to Marketing.
- 13: Post the CSS course file to the Content Management System.
- 21: Provide a hard copy proof to Project Manager.
- 24: Deliver final course.
