# Libra Training Manual

Schedule from MS Project, 2005-08-01 to 2005-10-10.
Coleman Publishing
Our goal is to be first to market with a quality product!

## Calendars

- COLEMAN: Mon-Fri 08:00-12:00, 13:00-17:00; Sat-Sun off. Exceptions (off unless hours are given): 2005-09-05.

## Schedule

| ID | WBS | Task | Type | Duration | Start | Finish | Predecessors | Total slack |
| --- | --- | --- | --- | --- | --- | --- | --- | --- |
| 1 | 1 | Start Book | milestone | 0d | 2005-08-01 | 2005-08-01 |  | 0d |
| 2 | 2 | **Research Phase** |  | 9d | 2005-08-01 | 2005-08-11 |  | 0d |
| 3 | 2.1 | Interview Subject Matter Experts |  | 2d | 2005-08-01 | 2005-08-02 | 1 | 0d |
| 4 | 2.2 | Investigate the software |  | 5d | 2005-08-03 | 2005-08-09 | 3 | 0d |
| 5 | 2.3 | Search the Web |  | 2d | 2005-08-10 | 2005-08-11 | 4 | 0d |
| 6 | 3 | **Outline Phase** |  | 5d | 2005-08-12 | 2005-08-18 |  | 0d |
| 7 | 3.1 | Create outline |  | 3d | 2005-08-12 | 2005-08-16 | 5 | 0d |
| 8 | 3.2 | Present to publisher |  | 1d | 2005-08-17 | 2005-08-17 | 7 | 0d |
| 9 | 3.3 | Review with Subject Matter Expert |  | 1d | 2005-08-17 | 2005-08-17 | 8SS | 0d |
| 10 | 3.4 | Revise outline |  | 1d | 2005-08-18 | 2005-08-18 | 9 | 0d |
| 11 | 4 | **Development Phase** |  | 30d | 2005-08-19 | 2005-09-30 |  | 0d |
| 12 | 4.1 | Write content |  | 25d | 2005-08-19 | 2005-09-23 | 10 | 0d |
| 13 | 4.2 | Add graphics |  | 5d | 2005-09-26 | 2005-09-30 | 12 | 0d |
| 14 | 5 | **Edit Phase** |  | 3d | 2005-09-28 | 2005-10-03 |  | 0d |
| 15 | 5.1 | Check grammar, spelling, and proofread |  | 3d | 2005-09-28 | 2005-10-03 | 13FS-5% | 0d |
| 16 | 5.2 | Check for technical accuracy |  | 2d | 2005-09-29 | 2005-10-03 | 15FF | 0d |
| 17 | 6 | **Review Phase** |  | 2d | 2005-10-03 | 2005-10-05 |  | 0d |
| 18 | 6.1 | Approve editing changes |  | 1d | 2005-10-03 | 2005-10-04 | 16 | 0d |
| 19 | 6.2 | Meet with editor |  | 1d | 2005-10-04 | 2005-10-05 | 18 | 0d |
| 20 | 7 | **Print Phase** |  | 3d | 2005-10-05 | 2005-10-10 |  | 0d |
| 21 | 7.1 | Print proof |  | 1d | 2005-10-05 | 2005-10-06 | 19 | 0d |
| 22 | 7.2 | Review proof |  | 1d | 2005-10-06 | 2005-10-07 | 21 | 0d |
| 23 | 7.3 | Print final |  | 1d | 2005-10-07 | 2005-10-10 | 22 | 0d |
| 24 | 8 | Book Complete | milestone | 0d | 2005-10-10 | 2005-10-10 | 23 | 0d |

Notes:
- 7: Post Outline.doc to the Marketing Web Page.
- 13: Post a Course.xml to the Content Management System.
- 21: Provide a hard copy proof to the Project Manager.
