# Refurbish New Offices

Schedule from MS Project, 2005-02-07 to 2005-02-21, costs in $.
Coleman Publishing

## Calendars

- Standard: Mon-Fri 08:00-12:00, 13:00-17:00; Sat-Sun off.

## Resources

| Resource | Rate |
| --- | --- |
| Painter 1 | 35 |
| Laborer | 25 |
| Technician | 40 |
| Painter 2 | 35 |

## Schedule

| ID | WBS | Task | Type | Duration | Start | Finish | Predecessors | Baseline start | Baseline finish | Baseline duration | Total slack | Resources | Work | Cost | Baseline cost |
| --- | --- | --- | --- | --- | --- | --- | --- | --- | --- | --- | --- | --- | --- | --- | --- |
| 1 | 1 | Project start | milestone | 0d | 2005-02-07 | 2005-02-07 |  | 2005-02-07 | 2005-02-07 | 0d | 0d |  |  |  |  |
| 2 | 2 | Paint the east walls |  | 1d | 2005-02-07 | 2005-02-07 | 1 | 2005-02-07 | 2005-02-07 | 1d | 0d | Painter 1 | 8h | 280 | 280 |
| 3 | 3 | Paint the west walls |  | 1d | 2005-02-07 | 2005-02-07 | 2SS | 2005-02-07 | 2005-02-07 | 1d | 0d | Painter 2 | 8h | 280 | 280 |
| 4 | 4 | Install partitions |  | 1d | 2005-02-08 | 2005-02-08 | 3 | 2005-02-08 | 2005-02-08 | 1d | 0d | Laborer | 8h | 200 | 200 |
| 5 | 5 | Install network cables |  | 2.5d | 2005-02-08 | 2005-02-10 | 4SS | 2005-02-08 | 2005-02-10 | 2.5d | 0d | Technician; Laborer | 24h | 780 | 780 |
| 6 | 6 | Lay carpet |  | 2d | 2005-02-10 | 2005-02-14 | 5 | 2005-02-10 | 2005-02-14 | 2d | 0d | Laborer | 16h | 400 | 400 |
| 7 | 7 | **Prepare offices** |  | 5d | 2005-02-14 | 2005-02-21 |  | 2005-02-14 | 2005-02-21 | 5d | 0d |  | 40h | 1,120 | 1,120 |
| 8 | 7.1 | Assemble furniture |  | 2d | 2005-02-14 | 2005-02-16 | 6 | 2005-02-14 | 2005-02-16 | 2d | 0d | Laborer | 16h | 400 | 400 |
| 9 | 7.2 | Hook up computers |  | 1d | 2005-02-16 | 2005-02-17 | 8 | 2005-02-16 | 2005-02-17 | 1d | 0d | Technician | 8h | 320 | 320 |
| 10 | 7.3 | Move in belongings |  | 2d | 2005-02-17 | 2005-02-21 | 9 | 2005-02-17 | 2005-02-21 | 2d | 0d | Laborer | 16h | 400 | 400 |
| 11 | 8 | Project end | milestone | 0d | 2005-02-21 | 2005-02-21 | 10 | 2005-02-21 | 2005-02-21 | 0d | 0d |  |  |  |  |
