# HTML Training Manual

Schedule from MS Project, 2005-10-31 to 2006-01-24, costs in $.
Coleman Publishing
Our goal is to be first to market with a quality product!

## Calendars

- COLEMAN: Mon-Fri 08:00-12:00, 13:00-17:00; Sat-Sun off. Exceptions (off unless hours are given): 2005-11-24 to 2005-11-25, 2005-12-19 08:00-12:00, 2005-12-23, 2005-12-26.

## Resources

| Resource | Group | Rate | Notes |
| --- | --- | --- | --- |
| Writer 2 |  | 45 | Software expert. |
| Editor 2 |  | 17 | Style expert. |
| Printer 2 |  | 10 | Flexible hours. |
| Artist 2 |  | 25 | Callouts, custom figures. |
| Project Manager 2 |  | 12 | Specializes in mid-range projects. |
| Staff Assistant 2 |  | 20 | Efficient. |
| Account Rep 2 |  | 48.08 | Sales-oriented. |
| Publisher 2 |  | 100 | Calm. |
| Subject Matter Expert 2 | External | 150 | From TC Agency. |
| Plain paper |  | 75 | For printing the proof. |

## Schedule

| ID | WBS | Task | Type | Duration | Start | Finish | Predecessors | Baseline start | Baseline finish | Baseline duration | Total slack | Free slack | Constraint | Resources | Work | Cost | Baseline cost |
| --- | --- | --- | --- | --- | --- | --- | --- | --- | --- | --- | --- | --- | --- | --- | --- | --- | --- |
| 1 | 1 | Start Book | milestone | 0d | 2005-10-31 | 2005-10-31 |  | 2005-10-31 | 2005-10-31 | 0d | 57.5d |  |  | Writer 2 |  |  |  |
| 2 | 2 | **Research Phase** |  | 7.5d | 2005-10-31 | 2005-11-09 |  | 2005-10-31 | 2005-11-09 | 7.5d | 4d |  |  |  | 88h | 4,092 | 4,092 |
| 3 | 2.1 | Interview Subject Matter Expert |  | 1.5d | 2005-10-31 | 2005-11-01 |  | 2005-10-31 | 2005-11-01 | 1.5d | 4d | 0d |  | Writer 2; Publisher 2 | 24h | 1,740 | 1,740 |
| 4 | 2.2 | Investigate the software |  | 4d | 2005-11-01 | 2005-11-07 | 3 | 2005-11-01 | 2005-11-07 | 4d | 4d | 0d |  | Writer 2 | 32h | 1,440 | 1,440 |
| 5 | 2.3 | Search the Web |  | 2d | 2005-11-07 | 2005-11-09 | 4 | 2005-11-07 | 2005-11-09 | 2d | 4d | 0d |  | Writer 2; Project Manager 2 | 32h | 912 | 912 |
| 6 | 3 | **Outline Phase** |  | 12.5d | 2005-11-09 | 2005-11-29 |  | 2005-11-09 | 2005-11-29 | 12.5d | 0.5d |  |  |  | 102h | 5,494.61 | 5,494.61 |
| 7 | 3.1 | Create outline |  | 3d | 2005-11-09 | 2005-11-14 | 5 | 2005-11-09 | 2005-11-14 | 3d | 4d | 0d |  | Writer 2 | 24h | 1,080 | 1,080 |
| 8 | 3.2 | Present to publisher |  | 1d | 2005-11-14 | 2005-11-15 | 7 | 2005-11-14 | 2005-11-15 | 1d | 4d | 3.5d |  | Writer 2; Account Rep 2 | 16h | 744.61 | 744.61 |
| 9 | 3.3 | Review with Subject Matter Expert |  | 2.25d | 2005-11-18 | 2005-11-22 | 8SS | 2005-11-18 | 2005-11-22 | 2.25d | 0.5d | 0d | start no earlier than 2005-11-18 | Writer 2; Publisher 2 | 32h | 2,320 | 2,320 |
| 10 | 3.4 | Revise outline |  | 3.75d | 2005-11-22 | 2005-11-29 | 9 | 2005-11-22 | 2005-11-29 | 3.75d | 0.5d | 0d |  | Writer 2 | 30h | 1,350 | 1,350 |
| 11 | 4 | **Development Phase** |  | 27d | 2005-11-30 | 2006-01-10 |  | 2005-11-30 | 2006-01-10 | 27d | 0.5d |  |  |  | 256h | 9,400 | 9,400 |
| 12 | 4.1 | Write content |  | 22d | 2005-11-30 | 2006-01-03 | 10 | 2005-11-30 | 2006-01-03 | 22d | 0.5d | 0d |  | Writer 2 | 176h | 7,920 | 7,920 |
| 13 | 4.2 | Add graphics |  | 5d | 2006-01-03 | 2006-01-10 | 12 | 2006-01-03 | 2006-01-10 | 5d | 0.5d | 0d |  | Artist 2; Project Manager 2 | 80h | 1,480 | 1,480 |
| 14 | 5 | **Edit Phase** |  | 5d | 2006-01-10 | 2006-01-17 |  | 2006-01-10 | 2006-01-17 | 5d | 0d |  |  |  | 56h | 2,280 | 2,280 |
| 15 | 5.1 | Check grammar, spelling, and proofread |  | 3d | 2006-01-10 | 2006-01-13 | 13 | 2006-01-10 | 2006-01-13 | 3d | 0.5d |  |  | Editor 2 | 24h | 408 | 408 |
| 16 | 5.2 | Check for technical accuracy |  | 2d | 2006-01-13 | 2006-01-17 | 15FF | 2006-01-13 | 2006-01-17 | 2d | 0d |  |  | Editor 2; Publisher 2 | 32h | 1,872 | 1,872 |
| 17 | 6 | **Review Phase** |  | 2d | 2006-01-17 | 2006-01-19 |  | 2006-01-17 | 2006-01-19 | 2d | 0d |  |  |  | 24h | 856 | 856 |
| 18 | 6.1 | Approve editing changes |  | 1d | 2006-01-17 | 2006-01-18 | 16 | 2006-01-17 | 2006-01-18 | 1d | 0d |  |  | Writer 2 | 8h | 360 | 360 |
| 19 | 6.2 | Meet with editor |  | 1d | 2006-01-18 | 2006-01-19 | 18 | 2006-01-18 | 2006-01-19 | 1d | 0d |  |  | Writer 2; Editor 2 | 16h | 496 | 496 |
| 20 | 7 | **Print Phase** |  | 3.5d | 2006-01-19 | 2006-01-24 |  | 2006-01-19 | 2006-01-24 | 3.5d | 0d |  |  |  | 40h | 1,129 | 1,129 |
| 21 | 7.1 | Print proof |  | 1d | 2006-01-19 | 2006-01-20 | 19 | 2006-01-19 | 2006-01-20 | 1d | 0d |  |  | Printer 2; Plain paper | 8h | 155 | 155 |
| 22 | 7.2 | Review proof |  | 1.5d | 2006-01-20 | 2006-01-23 | 21 | 2006-01-20 | 2006-01-23 | 1.5d | 0d |  |  | Writer 2; Editor 2 | 24h | 744 | 744 |
| 23 | 7.3 | Print final |  | 1d | 2006-01-24 | 2006-01-24 | 22 | 2006-01-24 | 2006-01-24 | 1d | 0d |  |  | Printer 2; Subject Matter Expert 2 | 8h | 230 | 230 |
| 24 | 8 | Book Complete | milestone | 0d | 2006-01-24 | 2006-01-24 | 23 | 2006-01-24 | 2006-01-24 | 0d | 0d |  |  | Writer 2 |  |  |  |

Notes:
- 7: Send the outline to Marketing.
- 13: Post the course file to the Content Management System.
- 21: Provide a hard copy proof to Project Manager.
- 24: Deliver final course.
