# Phase 2: Define the Business Opportunity

Schedule from MS Project, 2005-09-12 to 2005-10-18, costs in $.
New Periodical Division
Coleman Publishing
This plan is to launch the new magazine and newsletter division.

## Calendars

- COLEMAN: Mon-Fri 08:00-12:00, 13:00-17:00; Sat-Sun off.

## Resources

| Resource | Rate |
| --- | --- |
| Business advisor | 30 |
| Peers | 25 |
| Lawyer | 150 |
| Government agency | 15 |
| Manager | 20 |
| Owners | 300 |
| Accountant | 18 |
| Banker | 25 |
| Information services | 100 |

## Schedule

| ID | WBS | Task | Type | Duration | Start | Finish | Predecessors | Total slack | Resources | Work | Cost |
| --- | --- | --- | --- | --- | --- | --- | --- | --- | --- | --- | --- |
| 1 | 1 | **Define the Market** |  | 13d | 2005-09-12 | 2005-09-28 |  | 0d |  | 104h | 3,120 |
| 2 | 1.1 | Access available information |  | 1d | 2005-09-12 | 2005-09-12 |  | 0d | Business advisor | 8h | 240 |
| 3 | 1.2 | Create market analysis plan |  | 2d | 2005-09-13 | 2005-09-14 | 2 | 0d | Business advisor | 16h | 480 |
| 4 | 1.3 | Implement market analysis plan |  | 5d | 2005-09-15 | 2005-09-21 | 3 | 0d | Business advisor | 40h | 1,200 |
| 5 | 1.4 | Identify competition |  | 2d | 2005-09-22 | 2005-09-23 | 4 | 0d | Business advisor | 16h | 480 |
| 6 | 1.5 | Summarize the market |  | 2d | 2005-09-26 | 2005-09-27 | 5 | 0d | Business advisor | 16h | 480 |
| 7 | 1.6 | Identify target market niche |  | 1d | 2005-09-28 | 2005-09-28 | 6 | 0d | Business advisor | 8h | 240 |
| 8 | 2 | **Identify Needed Materials and Supplies** |  | 7d | 2005-09-29 | 2005-10-07 |  | 0d |  | 56h | 1,120 |
| 9 | 2.1 | Select a business approach (from "Evaluate Business Approach" above) |  | 2d | 2005-09-29 | 2005-09-30 | 2SS, 7 | 0d | Manager | 16h | 320 |
| 10 | 2.2 | Identify management staff resources |  | 1d | 2005-10-03 | 2005-10-03 | 9 | 0d | Manager | 8h | 160 |
| 11 | 2.3 | Identify staffing requirements |  | 1d | 2005-10-04 | 2005-10-04 | 10 | 0d | Manager | 8h | 160 |
| 12 | 2.4 | Identify needed raw materials |  | 1d | 2005-10-05 | 2005-10-05 | 11 | 0d | Manager | 8h | 160 |
| 13 | 2.5 | Identify needed utilities |  | 1d | 2005-10-06 | 2005-10-06 | 12 | 0d | Manager | 8h | 160 |
| 14 | 2.6 | Summarize operating expenses and financial projections |  | 1d | 2005-10-07 | 2005-10-07 | 13 | 0d | Manager | 8h | 160 |
| 15 | 3 | **Evaluate Potential Risks and Rewards** |  | 6d | 2005-10-10 | 2005-10-17 |  | 0d |  | 48h | 928 |
| 16 | 3.1 | Assess market size and stability |  | 2d | 2005-10-10 | 2005-10-11 | 14 | 0d | Manager | 16h | 320 |
| 17 | 3.2 | Assess needed resources availability |  | 2d | 2005-10-12 | 2005-10-13 | 16 | 0d | Manager | 16h | 320 |
| 18 | 3.3 | Forecast financial returns |  | 2d | 2005-10-14 | 2005-10-17 | 17 | 0d | Accountant | 16h | 288 |
| 19 | 4 | Review and modify the business opportunity |  | 1d | 2005-10-18 | 2005-10-18 | 18 | 0d |  |  |  |
| 20 | 5 | Confirm decision to proceed | milestone | 0d | 2005-10-18 | 2005-10-18 | 19 | 0d | Business advisor; Peers; Lawyer; Accountant |  |  |
