# Phase 3: Plan for Action

Schedule from MS Project, 2005-10-24 to 2005-11-21, costs in $.
New Periodical Division
Coleman Publishing
This plan is to launch the new magazine and newsletter division.

## Calendars

- COLEMAN: Mon-Fri 08:00-12:00, 13:00-17:00; Sat-Sun off.

## Resources

| Resource | Rate |
| --- | --- |
| Business advisor | 30 |
| Peers | 25 |
| Lawyer | 150 |
| Government agency | 15 |
| Manager | 20 |
| Owners | 300 |
| Accountant | 18 |
| Banker | 25 |
| Information services | 100 |

## Schedule

| ID | WBS | Task | Type | Duration | Start | Finish | Predecessors | Total slack | Resources | Work | Cost |
| --- | --- | --- | --- | --- | --- | --- | --- | --- | --- | --- | --- |
| 1 | 1 | **Develop Detailed 5-Year Business Plan** |  | 21d | 2005-10-24 | 2005-11-21 |  | 0d |  | 184h | 5,328 |
| 2 | 1.1 | Describe the vision and opportunity |  | 1d | 2005-10-24 | 2005-10-24 |  | 0d | Business advisor | 8h | 240 |
| 3 | 1.2 | List assumptions |  | 1d | 2005-10-25 | 2005-10-25 | 2 | 0d | Business advisor | 8h | 240 |
| 4 | 1.3 | Describe the market |  | 1d | 2005-10-26 | 2005-10-26 | 3 | 0d | Business advisor | 8h | 240 |
| 5 | 1.4 | Describe the new business |  | 1d | 2005-10-27 | 2005-10-27 | 4 | 0d | Business advisor | 8h | 240 |
| 6 | 1.5 | Describe strengths, weaknesses, assets and threats |  | 1d | 2005-10-28 | 2005-10-28 | 5 | 0d | Business advisor | 8h | 240 |
| 7 | 1.6 | Estimate sales volume during startup period |  | 1d | 2005-10-31 | 2005-10-31 | 6 | 0d | Business advisor; Accountant | 16h | 384 |
| 8 | 1.7 | Forecast operating costs |  | 1d | 2005-11-01 | 2005-11-01 | 7 | 0d | Business advisor; Accountant | 16h | 384 |
| 9 | 1.8 | Establish pricing strategy |  | 1d | 2005-11-02 | 2005-11-02 | 8 | 0d | Business advisor | 8h | 240 |
| 10 | 1.9 | Forecast revenue |  | 1d | 2005-11-03 | 2005-11-03 | 9 | 0d | Business advisor | 8h | 240 |
| 11 | 1.10 | Summarize pro-forma financial statement |  | 2d | 2005-11-04 | 2005-11-07 | 10 | 0d | Business advisor | 16h | 480 |
| 12 | 1.11 | Develop break-even analysis |  | 1d | 2005-11-08 | 2005-11-08 | 11 | 0d | Business advisor | 8h | 240 |
| 13 | 1.12 | Develop cash-flow projection |  | 1d | 2005-11-09 | 2005-11-09 | 12 | 0d | Business advisor | 8h | 240 |
| 14 | 1.13 | Identify licensing and permitting requirements |  | 1d | 2005-11-10 | 2005-11-10 | 13 | 0d | Business advisor | 8h | 240 |
| 15 | 1.14 | Develop startup plan |  | 2d | 2005-11-11 | 2005-11-14 | 14 | 0d | Business advisor | 16h | 480 |
| 16 | 1.15 | Develop sales and marketing strategy |  | 1d | 2005-11-15 | 2005-11-15 | 15 | 0d | Business advisor | 8h | 240 |
| 17 | 1.16 | Develop distribution structure |  | 1d | 2005-11-16 | 2005-11-16 | 16 | 0d | Business advisor | 8h | 240 |
| 18 | 1.17 | Describe risks and opportunities |  | 2d | 2005-11-17 | 2005-11-18 | 17 | 0d | Business advisor | 16h | 480 |
| 19 | 1.18 | Publish the business plan |  | 1d | 2005-11-21 | 2005-11-21 | 18 | 0d | Business advisor | 8h | 240 |
| 20 | 1.19 | Confirm decision to proceed | milestone | 0d | 2005-11-21 | 2005-11-21 | 19 | 0d | Business advisor |  |  |
