# Phase 4: Proceed With Startup Plan

Schedule from MS Project, 2005-11-28 to 2006-02-17, costs in $.
New Periodical Division
Coleman Publishing
This plan is to launch the new magazine and newsletter division.

## Calendars

- COLEMAN: Mon-Fri 08:00-12:00, 13:00-17:00; Sat-Sun off.

## Resources

| Resource | Rate |
| --- | --- |
| Business advisor | 30 |
| Peers | 25 |
| Lawyer | 150 |
| Government agency | 15 |
| Manager | 20 |
| Owners | 300 |
| Accountant | 18 |
| Banker | 25 |
| Information services | 100 |

## Schedule

| ID | WBS | Task | Type | Duration | Start | Finish | Predecessors | Total slack | Free slack | Resources | Work | Cost |
| --- | --- | --- | --- | --- | --- | --- | --- | --- | --- | --- | --- | --- |
| 1 | 1 | Choose a location |  | 1d | 2005-11-28 | 2005-11-28 |  | 0d |  |  |  |  |
| 2 | 2 | **Establish Business Structure** |  | 23d | 2005-11-29 | 2005-12-29 |  | 0d |  |  | 296h | 18,792 |
| 3 | 2.1 | **Choose a Name** |  | 2d | 2005-11-29 | 2005-11-30 |  | 0d |  |  | 16h | 2,400 |
| 4 | 2.1.1 | Identify implications |  | 1d | 2005-11-29 | 2005-11-29 | 1 | 0d |  | Lawyer | 8h | 1,200 |
| 5 | 2.1.2 | Research name availability |  | 1d | 2005-11-30 | 2005-11-30 | 4 | 0d |  | Lawyer | 8h | 1,200 |
| 6 | 2.2 | **Choose a Bank** |  | 5d | 2005-12-01 | 2005-12-07 |  | 0d |  |  | 40h | 1,000 |
| 7 | 2.2.1 | Establish accounts |  | 4d | 2005-12-01 | 2005-12-06 | 5 | 0d |  | Banker | 32h | 800 |
| 8 | 2.2.2 | Establish line of credit |  | 1d | 2005-12-07 | 2005-12-07 | 7 | 0d |  | Banker | 8h | 200 |
| 9 | 2.3 | Choose legal representation |  | 1d | 2005-12-07 | 2005-12-07 | 7SS, 8SS | 0d |  | Lawyer | 8h | 1,200 |
| 10 | 2.4 | Select business tax-basis category |  | 2d | 2005-12-08 | 2005-12-09 | 9 | 0d |  | Lawyer; Accountant | 32h | 2,688 |
| 11 | 2.5 | Choose capital funding source |  | 2d | 2005-12-12 | 2005-12-13 | 10 | 0d |  | Manager | 16h | 320 |
| 12 | 2.6 | Commit capital funding | milestone | 0d | 2005-12-13 | 2005-12-13 | 11 | 0d |  | Manager |  |  |
| 13 | 2.7 | **Establish the Operating Control Base** |  | 12d | 2005-12-14 | 2005-12-29 |  | 0d |  |  | 144h | 9,024 |
| 14 | 2.7.1 | Choose and set up the accounting system |  | 2d | 2005-12-14 | 2005-12-15 | 11, 12 | 0d |  | Accountant | 16h | 288 |
| 15 | 2.7.2 | Obtain required licenses and permits |  | 4d | 2005-12-16 | 2005-12-21 | 14 | 0d |  | Lawyer; Government agency | 64h | 5,280 |
| 16 | 2.7.3 | Obtain needed insurance |  | 4d | 2005-12-22 | 2005-12-27 | 15 | 0d |  | Accountant | 32h | 576 |
| 17 | 2.7.4 | Establish security plan |  | 2d | 2005-12-28 | 2005-12-29 | 16 | 0d |  | Business advisor; Lawyer | 32h | 2,880 |
| 18 | 2.8 | **Develop Marketing Program** |  | 4d | 2005-11-30 | 2005-12-05 |  | 18d |  |  | 40h | 2,160 |
| 19 | 2.8.1 | Establish an advertising program |  | 2d | 2005-11-30 | 2005-12-01 | 5SS | 18d | 0d | Business advisor | 16h | 480 |
| 20 | 2.8.2 | Develop a logo |  | 1d | 2005-12-02 | 2005-12-02 | 19 | 18d | 0d | Business advisor; Lawyer | 16h | 1,440 |
| 21 | 2.8.3 | Order promotional materials |  | 1d | 2005-12-05 | 2005-12-05 | 20 | 18d |  | Business advisor | 8h | 240 |
| 22 | 3 | **Provide Physical Facilities** |  | 36d | 2005-12-30 | 2006-02-17 |  | 0d |  |  | 120h | 8,880 |
| 23 | 3.1 | Secure operation space |  | 5d | 2005-12-30 | 2006-01-05 | 17, 21 | 0d |  | Lawyer | 40h | 6,000 |
| 24 | 3.2 | Select computer network hardware |  | 1d | 2006-01-06 | 2006-01-06 | 23 | 0d |  | Information services | 8h | 800 |
| 25 | 3.3 | Select computer software |  | 1d | 2006-01-09 | 2006-01-09 | 24 | 0d |  | Information services | 8h | 800 |
| 26 | 3.4 | Establish utilities |  | 3d | 2006-01-17 | 2006-01-19 | 25 | 0d |  | Manager | 24h | 480 |
| 27 | 3.5 | Provide furniture and equipment |  | 4d | 2006-01-20 | 2006-01-25 | 26 | 0d |  | Manager | 32h | 640 |
| 28 | 3.6 | Move in |  | 1d | 2006-02-17 | 2006-02-17 | 27 | 0d |  | Manager | 8h | 160 |

| ID | WBS | Task | Type | Duration | Start | Finish | Predecessors | Total slack | Free slack | Resources | Work | Cost |
| --- | --- | --- | --- | --- | --- | --- | --- | --- | --- | --- | --- | --- |
| 29 | 4 | **Provide Staffing** |  | 47d | 2005-12-14 | 2006-02-16 |  | 1d |  |  | 320h | 6,400 |
| 30 | 4.1 | Interview and test candidates |  | 14d | 2005-12-14 | 2006-01-02 | 11 | 1d | 0d | Manager | 112h | 2,240 |
| 31 | 4.2 | Hire staff |  | 10d | 2006-01-03 | 2006-01-16 | 30 | 1d | 0d | Manager | 80h | 1,600 |
| 32 | 4.3 | Train staff |  | 16d | 2006-01-26 | 2006-02-16 | 31 | 1d |  | Manager | 128h | 2,560 |
| 33 | 5 | Start up the business | milestone | 0d | 2006-02-17 | 2006-02-17 | 28, 32 | 0d |  | Manager |  |  |
