# Refurbish New Offices

Schedule from MS Project, 2005-02-07 to 2005-02-22, costs in $.
Coleman Publishing

## Calendars

- Standard: Mon-Fri 08:00-12:00, 13:00-17:00; Sat-Sun off.

## Resources

| Resource | Rate |
| --- | --- |
| Painter | 35 |
| Laborer | 25 |
| Technician | 40 |

## Schedule

| ID | WBS | Task | Type | Duration | Start | Finish | Predecessors | Total slack | Resources | Work | Cost |
| --- | --- | --- | --- | --- | --- | --- | --- | --- | --- | --- | --- |
| 1 | 1 | Project start | milestone | 0d | 2005-02-07 | 2005-02-07 |  | 0d |  |  |  |
| 2 | 2 | Paint the walls |  | 2d | 2005-02-07 | 2005-02-08 | 1 | 0d | Painter | 16h | 560 |
| 3 | 3 | Install partitions |  | 1d | 2005-02-09 | 2005-02-09 | 2 | 0d | Laborer | 8h | 200 |
| 4 | 4 | Install network cables |  | 3d | 2005-02-09 | 2005-02-11 | 3SS | 0d | Technician | 24h | 960 |
| 5 | 5 | Lay carpet |  | 2d | 2005-02-14 | 2005-02-15 | 4 | 0d | Laborer | 16h | 400 |
| 6 | 6 | **Prepare offices** |  | 5d | 2005-02-16 | 2005-02-22 |  | 0d |  |  |  |
| 7 | 6.1 | Assemble furniture |  | 2d | 2005-02-16 | 2005-02-17 | 5 | 0d |  |  |  |
| 8 | 6.2 | Hook up computers |  | 1d | 2005-02-18 | 2005-02-18 | 7 | 0d |  |  |  |
| 9 | 6.3 | Move in belongings |  | 2d | 2005-02-21 | 2005-02-22 | 8 | 0d |  |  |  |
| 10 | 7 | Project complete | milestone | 0d | 2005-02-22 | 2005-02-22 | 9 | 0d |  |  |  |
