# HTML Training Manual

Schedule from MS Project, 2005-10-31 to 2006-01-20, costs in $.
Coleman Publishing
Our goal is to be first to market with a quality product!

## Calendars

- COLEMAN: Mon-Fri 08:00-12:00, 13:00-17:00; Sat-Sun off. Exceptions (off unless hours are given): 2005-11-24 to 2005-11-25, 2005-12-19 08:00-12:00, 2005-12-23, 2005-12-26.

## Resources

| Resource | Group | Rate | Notes |
| --- | --- | --- | --- |
| Writer 3 |  | 45 | Software expert. |
| Editor 3 |  | 17 | Style expert. |
| Printer 3 |  | 10 | Flexible hours. |
| Artist 3 |  | 25 | Callouts, custom figures. |
| Project Manager 3 |  | 12 | Specializes in mid-range projects. |
| Staff Assistant 3 |  | 20 | Efficient. |
| Account Rep 3 |  | 48.08 | Sales-oriented. |
| Publisher 3 |  | 100 | Calm. |
| Subject Matter Expert 3 | External | 150 | From TC Agency. |
| Plain paper | External | 75 | For printing the proof. |
| Glossy paper | External | 150 | For final printing. |

## Schedule

| ID | WBS | Task | Type | Duration | Start | Finish | Predecessors | Baseline start | Baseline finish | Baseline duration | Total slack | Free slack | Constraint | Resources | Work | Cost | Baseline cost |
| --- | --- | --- | --- | --- | --- | --- | --- | --- | --- | --- | --- | --- | --- | --- | --- | --- | --- |
| 1 | 1 | Start Book | milestone | 0d | 2005-10-31 | 2005-10-31 |  | 2005-10-31 | 2005-10-31 | 0d | 55.5d |  |  | Writer 3 |  |  |  |
| 2 | 2 | **Research Phase** |  | 7.5d | 2005-10-31 | 2005-11-09 |  | 2005-10-31 | 2005-11-09 | 7.5d | 1.5d |  |  |  | 88h | 4,092 | 4,092 |
| 3 | 2.1 | Interview Subject Matter Expert |  | 1.5d | 2005-10-31 | 2005-11-01 |  | 2005-10-31 | 2005-11-01 | 1.5d | 1.5d | 0d |  | Writer 3; Publisher 3 | 24h | 1,740 | 1,740 |
| 4 | 2.2 | Investigate the software |  | 4d | 2005-11-01 | 2005-11-07 | 3 | 2005-11-01 | 2005-11-07 | 4d | 1.5d | 0d |  | Writer 3 | 32h | 1,440 | 1,440 |
| 5 | 2.3 | Search the Web |  | 2d | 2005-11-07 | 2005-11-09 | 4 | 2005-11-07 | 2005-11-09 | 2d | 1.5d | 0d |  | Writer 3; Project Manager 3 | 32h | 912 | 912 |
| 6 | 3 | **Outline Phase** |  | 10.5d | 2005-11-09 | 2005-11-23 |  | 2005-11-09 | 2005-11-23 | 10.5d | 0d |  |  |  | 102h | 5,494.61 | 5,494.61 |
| 7 | 3.1 | Create outline |  | 3d | 2005-11-09 | 2005-11-14 | 5 | 2005-11-09 | 2005-11-14 | 3d | 1.5d | 0d |  | Writer 3 | 24h | 1,080 | 1,080 |
| 8 | 3.2 | Present to publisher |  | 1d | 2005-11-14 | 2005-11-15 | 7 | 2005-11-14 | 2005-11-15 | 1d | 1.5d |  |  | Writer 3; Account Rep 3 | 16h | 744.61 | 744.61 |
| 9 | 3.3 | Review with Subject Matter Expert |  | 2.25d | 2005-11-16 | 2005-11-18 | 8SS | 2005-11-16 | 2005-11-18 | 2.25d | 0d |  | start no earlier than 2005-11-16 | Writer 3; Publisher 3 | 32h | 2,320 | 2,320 |
| 10 | 3.4 | Revise outline |  | 3.75d | 2005-11-18 | 2005-11-23 | 9 | 2005-11-18 | 2005-11-23 | 3.75d | 0d |  |  | Writer 3 | 30h | 1,350 | 1,350 |
| 11 | 4 | **Development Phase** |  | 27d | 2005-11-28 | 2006-01-06 |  | 2005-11-28 | 2006-01-06 | 27d | 0d |  |  |  | 256h | 9,400 | 9,400 |
| 12 | 4.1 | Write content |  | 22d | 2005-11-28 | 2005-12-30 | 10 | 2005-11-28 | 2005-12-30 | 22d | 0d |  |  | Writer 3 | 176h | 7,920 | 7,920 |
| 13 | 4.2 | Add graphics |  | 5d | 2005-12-30 | 2006-01-06 | 12 | 2005-12-30 | 2006-01-06 | 5d | 0d |  |  | Artist 3; Project Manager 3 | 80h | 1,480 | 1,480 |
| 14 | 5 | **Edit Phase** |  | 5d | 2006-01-06 | 2006-01-13 |  | 2006-01-06 | 2006-01-13 | 5d | 0d |  |  |  | 56h | 2,280 | 2,280 |
| 15 | 5.1 | Check grammar, spelling, and proofread |  | 3d | 2006-01-06 | 2006-01-11 | 13 | 2006-01-06 | 2006-01-11 | 3d | 0d |  |  | Editor 3 | 24h | 408 | 408 |
| 16 | 5.2 | Check for technical accuracy |  | 2d | 2006-01-11 | 2006-01-13 | 15FF | 2006-01-11 | 2006-01-13 | 2d | 0d |  |  | Editor 3; Publisher 3 | 32h | 1,872 | 1,872 |
| 17 | 6 | **Review Phase** |  | 2d | 2006-01-13 | 2006-01-17 |  | 2006-01-13 | 2006-01-17 | 2d | 0d |  |  |  | 24h | 856 | 856 |
| 18 | 6.1 | Approve editing changes |  | 1d | 2006-01-13 | 2006-01-16 | 16 | 2006-01-13 | 2006-01-16 | 1d | 0d |  |  | Writer 3 | 8h | 360 | 360 |
| 19 | 6.2 | Meet with editor |  | 1d | 2006-01-16 | 2006-01-17 | 18 | 2006-01-16 | 2006-01-17 | 1d | 0d |  |  | Writer 3; Editor 3 | 16h | 496 | 496 |
| 20 | 7 | **Print Phase** |  | 3.5d | 2006-01-17 | 2006-01-20 |  | 2006-01-17 | 2006-01-20 | 3.5d | 0d |  |  |  | 40h | 1,129 | 1,129 |
| 21 | 7.1 | Print proof |  | 1d | 2006-01-17 | 2006-01-18 | 19 | 2006-01-17 | 2006-01-18 | 1d | 0d |  |  | Printer 3; Plain paper | 8h | 155 | 155 |
| 22 | 7.2 | Review proof |  | 1.5d | 2006-01-18 | 2006-01-19 | 21 | 2006-01-18 | 2006-01-19 | 1.5d | 0d |  |  | Writer 3; Editor 3 | 24h | 744 | 744 |
| 23 | 7.3 | Print final |  | 1d | 2006-01-20 | 2006-01-20 | 22 | 2006-01-20 | 2006-01-20 | 1d | 0d |  |  | Printer 3; Glossy paper | 8h | 230 | 230 |
| 24 | 8 | Book Complete | milestone | 0d | 2006-01-20 | 2006-01-20 | 23 | 2006-01-20 | 2006-01-20 | 0d | 0d |  |  | Writer 3 |  |  |  |

Notes:
- 7: Send the outline to Marketing.
- 13: Post the course file to the Content Management System.
- 21: Provide a hard copy proof to Project Manager.
- 24: Deliver final course.
