# Unix Training Manual

Schedule from MS Project, 2005-10-31 to 2006-01-25, costs in $.
elementk

## Calendars

- COLEMAN: Mon-Fri 08:00-12:00, 13:00-17:00; Sat-Sun off. Exceptions (off unless hours are given): 2005-11-24 to 2005-11-25, 2005-12-19 08:00-12:00, 2005-12-23, 2005-12-26.

## Resources

| Resource | Group | Rate | Notes |
| --- | --- | --- | --- |
| Writer 4 |  | 35 | Software expert. |
| Editor 4 |  | 20 | Style expert. |
| Printer 4 |  | 15 | Accommodating. |
| Artist 4 |  | 20 | Callouts, custom figures. |
| Project Manager 4 |  | 40 | Specializes in small projects. |
| Staff Assistant 4 |  | 15 | Competent. |
| Account Rep 4 |  | 15 | Creative. |
| Publisher 4 |  | 110 | Hands-off manager. |
| Subject Matter Expert 4 | External | 100 | From AAA Agency. |
| Glossy paper | External | 150 | For final printing. |
| Plain paper | External | 75 | For printing the proof. |

## Schedule

| ID | WBS | Task | Type | Duration | Start | Finish | Predecessors | Baseline start | Baseline finish | Baseline duration | Total slack | Free slack | Constraint | Resources | Work | Cost | Baseline cost |
| --- | --- | --- | --- | --- | --- | --- | --- | --- | --- | --- | --- | --- | --- | --- | --- | --- | --- |
| 1 | 1 | Start Book | milestone | 0d | 2005-10-31 | 2005-10-31 |  | 2005-10-31 | 2005-10-31 | 0d | 57.75d |  |  | Project Manager 4; Writer 4 |  |  |  |
| 2 | 2 | **Research Phase** |  | 7d | 2005-10-31 | 2005-11-08 |  | 2005-10-31 | 2005-11-08 | 7d | 4d |  |  |  | 96h | 4,320 | 4,320 |
| 3 | 2.1 | Interview Subject Matter Expert |  | 2d | 2005-10-31 | 2005-11-01 |  | 2005-10-31 | 2005-11-01 | 2d | 4d | 0d |  | Project Manager 4; Writer 4; Subject Matter Expert 4 | 48h | 2,800 | 2,800 |
| 4 | 2.2 | Investigate Unix |  | 4d | 2005-11-02 | 2005-11-07 | 3 | 2005-11-02 | 2005-11-07 | 4d | 4d | 0d |  | Writer 4 | 32h | 1,120 | 1,120 |
| 5 | 2.3 | Search the Web |  | 1d | 2005-11-08 | 2005-11-08 | 4 | 2005-11-08 | 2005-11-08 | 1d | 4d | 0d |  | Writer 4; Staff Assistant 4 | 16h | 400 | 400 |
| 6 | 3 | **Outline Phase** |  | 13.75d | 2005-11-09 | 2005-11-30 |  | 2005-11-09 | 2005-11-28 | 11.75d | 0d |  |  |  | 126h | 6,610 | 6,610 |
| 7 | 3.1 | Create outline |  | 3d | 2005-11-09 | 2005-11-11 | 5 | 2005-11-09 | 2005-11-11 | 3d | 4d | 0d |  | Writer 4 | 24h | 840 | 840 |
| 8 | 3.2 | Present to publisher |  | 1d | 2005-11-14 | 2005-11-14 | 7 | 2005-11-14 | 2005-11-14 | 1d | 4d |  |  | Writer 4; Project Manager 4; Publisher 4 | 24h | 1,480 | 1,480 |
| 9 | 3.3 | Review with Subject Matter Expert |  | 3d | 2005-11-18 | 2005-11-22 | 8SS | 2005-11-18 | 2005-11-22 | 3d | 0d |  | start no earlier than 2005-11-18 | Writer 4; Subject Matter Expert 4 | 48h | 3,240 | 3,240 |
| 10 | 3.4 | Revise outline |  | 3.75d | 2005-11-23 | 2005-11-30 | 9 | 2005-11-23 | 2005-11-28 | 3.75d | 0d |  |  | Writer 4 | 30h | 1,050 | 1,050 |
| 11 | 4 | **Development Phase** |  | 27d | 2005-11-30 | 2006-01-11 |  | 2005-11-28 | 2006-01-04 | 24.5d | 0d |  |  |  | 256h | 7,560 | 7,560 |
| 12 | 4.1 | Write content |  | 22d | 2005-11-30 | 2006-01-04 | 10 | 2005-11-28 | 2005-12-28 | 22d | 0d |  |  | Writer 4 | 176h | 6,160 | 6,160 |
| 13 | 4.2 | Add graphics |  | 5d | 2006-01-04 | 2006-01-11 | 12 | 2005-12-28 | 2006-01-04 | 5d | 0d |  |  | Artist 4; Staff Assistant 4 | 80h | 1,400 | 1,400 |
| 14 | 5 | **Edit Phase** |  | 5d | 2006-01-11 | 2006-01-18 |  | 2006-01-04 | 2006-01-11 | 5d | 0d |  |  |  | 56h | 2,400 | 2,400 |
| 15 | 5.1 | Check grammar, spelling, and proofread |  | 3d | 2006-01-11 | 2006-01-16 | 13 | 2006-01-04 | 2006-01-09 | 3d | 0d |  |  | Editor 4 | 24h | 480 | 480 |
| 16 | 5.2 | Check for technical accuracy |  | 2d | 2006-01-16 | 2006-01-18 | 15FF | 2006-01-09 | 2006-01-11 | 2d | 0d |  |  | Editor 4; Subject Matter Expert 4 | 32h | 1,920 | 1,920 |
| 17 | 6 | **Review Phase** |  | 2d | 2006-01-18 | 2006-01-20 |  | 2006-01-11 | 2006-01-13 | 2d | 0d |  |  |  | 24h | 720 | 720 |
| 18 | 6.1 | Approve editing changes |  | 1d | 2006-01-18 | 2006-01-19 | 16 | 2006-01-11 | 2006-01-12 | 1d | 0d |  |  | Writer 4 | 8h | 280 | 280 |
| 19 | 6.2 | Meet with editor |  | 1d | 2006-01-19 | 2006-01-20 | 18 | 2006-01-12 | 2006-01-13 | 1d | 0d |  |  | Writer 4; Editor 4 | 16h | 440 | 440 |
| 20 | 7 | **Print Phase** |  | 3d | 2006-01-20 | 2006-01-25 |  | 2006-01-13 | 2006-01-18 | 3d | 0d |  |  |  | 40h | 1,225 | 1,225 |
| 21 | 7.1 | Print proof |  | 1d | 2006-01-20 | 2006-01-23 | 19 | 2006-01-13 | 2006-01-16 | 1d | 0d |  |  | Printer 4; Plain paper | 8h | 195 | 195 |
| 22 | 7.2 | Review proof |  | 1d | 2006-01-23 | 2006-01-24 | 21 | 2006-01-16 | 2006-01-17 | 1d | 0d |  |  | Writer 4; Editor 4; Project Manager 4 | 24h | 760 | 760 |
| 23 | 7.3 | Print final |  | 1d | 2006-01-24 | 2006-01-25 | 22 | 2006-01-17 | 2006-01-18 | 1d | 0d |  |  | Printer 4; Glossy paper | 8h | 270 | 270 |
| 24 | 8 | Book Complete | milestone | 0d | 2006-01-25 | 2006-01-25 | 23 | 2006-01-18 | 2006-01-18 | 0d | 0d |  |  | Project Manager 4; Writer 4 |  |  |  |

Notes:
- 7: Send the outline to Marketing.
- 13: Post the course file to the Content Management System.
- 21: Provide a hard copy proof to Project Manager.
- 24: Deliver final course.
