# XML Training Manual

Schedule from MS Project, 2005-10-31 to 2006-01-26, costs in $.
elementk

## Calendars

- COLEMAN: Mon-Fri 08:00-12:00, 13:00-17:00; Sat-Sun off. Exceptions (off unless hours are given): 2005-11-24 to 2005-11-25, 2005-12-19 08:00-12:00, 2005-12-23, 2005-12-26.

## Resources

| Resource | Rate | Notes |
| --- | --- | --- |
| Project Manager 2 | 40 | Specializes in mid-range projects. |
| Writer 2 | 35 | Software expert. |
| Subject Matter Expert 2 | 100 | From TC Agency. |
| Staff Assistant 2 | 15 | Efficient. |
| Publisher 2 | 110 | Calm. |
| Artist 2 | 20 | Callouts, custom figures. |
| Editor 2 | 20 | Style expert. |
| Printer 2 | 15 | Flexible hours. |
| Plain paper | 75 | For printing the proof. |
| Glossy paper | 150 | For final printing. |
| Account Rep 2 | 15 | Creative. |

## Schedule

| ID | WBS | Task | Type | Duration | Start | Finish | Predecessors | Baseline start | Baseline finish | Baseline duration | Total slack | Free slack | Constraint | Resources | Work | Cost | Baseline cost |
| --- | --- | --- | --- | --- | --- | --- | --- | --- | --- | --- | --- | --- | --- | --- | --- | --- | --- |
| 1 | 1 | Start Book | milestone | 0d | 2005-10-31 | 2005-10-31 |  | 2005-10-31 | 2005-10-31 | 0d | 59.25d |  |  | Project Manager 2; Writer 2 |  |  |  |
| 2 | 2 | **Research Phase** |  | 7d | 2005-10-31 | 2005-11-08 |  | 2005-10-31 | 2005-11-08 | 7d | 1d |  |  |  | 88h | 3,320 | 3,320 |
| 3 | 2.1 | Interview Subject Matter Expert |  | 1d | 2005-10-31 | 2005-10-31 |  | 2005-10-31 | 2005-10-31 | 1d | 1d | 0d |  | Project Manager 2; Writer 2; Subject Matter Expert 2 | 24h | 1,400 | 1,400 |
| 4 | 2.2 | Investigate XML |  | 4d | 2005-11-01 | 2005-11-04 | 3 | 2005-11-01 | 2005-11-04 | 4d | 1d | 0d |  | Writer 2 | 32h | 1,120 | 1,120 |
| 5 | 2.3 | Search the Web |  | 2d | 2005-11-07 | 2005-11-08 | 4 | 2005-11-07 | 2005-11-08 | 2d | 1d | 0d |  | Writer 2; Staff Assistant 2 | 32h | 800 | 800 |
| 6 | 3 | **Outline Phase** |  | 10.75d | 2005-11-09 | 2005-11-23 |  | 2005-11-09 | 2005-11-23 | 10.75d | 0d |  |  |  | 126h | 6,610 | 6,610 |
| 7 | 3.1 | Create outline |  | 3d | 2005-11-09 | 2005-11-11 | 5 | 2005-11-09 | 2005-11-11 | 3d | 1d | 0d |  | Writer 2 | 24h | 840 | 840 |
| 8 | 3.2 | Present to publisher |  | 1d | 2005-11-14 | 2005-11-14 | 7 | 2005-11-14 | 2005-11-14 | 1d | 1d |  |  | Writer 2; Project Manager 2; Publisher 2 | 24h | 1,480 | 1,480 |
| 9 | 3.3 | Review with Subject Matter Expert |  | 3d | 2005-11-15 | 2005-11-17 | 8SS | 2005-11-15 | 2005-11-17 | 3d | 0d |  | start no earlier than 2005-11-15 | Writer 2; Subject Matter Expert 2 | 48h | 3,240 | 3,240 |
| 10 | 3.4 | Revise outline |  | 3.75d | 2005-11-18 | 2005-11-23 | 9 | 2005-11-18 | 2005-11-23 | 3.75d | 0d |  |  | Writer 2 | 30h | 1,050 | 1,050 |
| 11 | 4 | **Development Phase** |  | 31.5d | 2005-11-23 | 2006-01-12 |  | 2005-11-23 | 2006-01-06 | 27d | 0d |  |  |  | 292h | 8,820 | 8,820 |
| 12 | 4.1 | Write content |  | 26.5d | 2005-11-23 | 2006-01-05 | 10 | 2005-11-23 | 2005-12-30 | 26.5d | 0d |  |  | Writer 2 | 212h | 7,420 | 7,420 |
| 13 | 4.2 | Add graphics |  | 5d | 2006-01-05 | 2006-01-12 | 12 | 2005-12-30 | 2006-01-06 | 5d | 0d |  |  | Artist 2; Staff Assistant 2 | 80h | 1,400 | 1,400 |
| 14 | 5 | **Edit Phase** |  | 5d | 2006-01-12 | 2006-01-19 |  | 2006-01-06 | 2006-01-13 | 5d | 0d |  |  |  | 56h | 2,400 | 2,400 |
| 15 | 5.1 | Check grammar, spelling, and proofread |  | 3d | 2006-01-12 | 2006-01-17 | 13 | 2006-01-06 | 2006-01-11 | 3d | 0d |  |  | Editor 2 | 24h | 480 | 480 |
| 16 | 5.2 | Check for technical accuracy |  | 2d | 2006-01-17 | 2006-01-19 | 15FF | 2006-01-11 | 2006-01-13 | 2d | 0d |  |  | Editor 2; Subject Matter Expert 2 | 32h | 1,920 | 1,920 |
| 17 | 6 | **Review Phase** |  | 2d | 2006-01-19 | 2006-01-23 |  | 2006-01-13 | 2006-01-17 | 2d | 0d |  |  |  | 24h | 720 | 720 |
| 18 | 6.1 | Approve editing changes |  | 1d | 2006-01-19 | 2006-01-20 | 16 | 2006-01-13 | 2006-01-16 | 1d | 0d |  |  | Writer 2 | 8h | 280 | 280 |
| 19 | 6.2 | Meet with editor |  | 1d | 2006-01-20 | 2006-01-23 | 18 | 2006-01-16 | 2006-01-17 | 1d | 0d |  |  | Writer 2; Editor 2 | 16h | 440 | 440 |
| 20 | 7 | **Print Phase** |  | 3d | 2006-01-23 | 2006-01-26 |  | 2006-01-17 | 2006-01-20 | 3d | 0d |  |  |  | 42h | 1,225 | 1,225 |
| 21 | 7.1 | Print proof |  | 1d | 2006-01-23 | 2006-01-24 | 19 | 2006-01-17 | 2006-01-18 | 1d | 0d |  |  | Printer 2; Plain paper | 9h | 195 | 195 |
| 22 | 7.2 | Review proof |  | 1d | 2006-01-24 | 2006-01-25 | 21 | 2006-01-18 | 2006-01-19 | 1d | 0d |  |  | Writer 2; Editor 2; Project Manager 2 | 24h | 760 | 760 |
| 23 | 7.3 | Print final |  | 1d | 2006-01-25 | 2006-01-26 | 22 | 2006-01-19 | 2006-01-20 | 1d | 0d |  |  | Printer 2; Glossy paper | 9h | 270 | 270 |
| 24 | 8 | Book Complete | milestone | 0d | 2006-01-26 | 2006-01-26 | 23 | 2006-01-20 | 2006-01-20 | 0d | 0d |  |  | Project Manager 2; Writer 2 |  |  |  |

Notes:
- 7: Send the outline to Marketing.
- 13: Post the course file to the Content Management System.
- 21: Provide a hard copy proof to Project Manager.
- 24: Deliver final course.
