# Training Manual

Schedule from MS Project, 2005-10-31 to 2006-01-18, costs in $.
Coleman Publishing
Our goal is to be first to market with a quality product!

## Calendars

- COLEMAN: Mon-Fri 08:00-12:00, 13:00-17:00; Sat-Sun off. Exceptions (off unless hours are given): 2005-11-24 to 2005-11-25, 2005-12-19 08:00-12:00, 2005-12-23, 2005-12-26.

## Resources

| Resource | Group | Rate | Notes |
| --- | --- | --- | --- |
| Writer 1 |  | 45 | Software expert. |
| Project Manager 1 |  | 60 | Specializes in short projects. |
| Subject Matter Expert 1 | External | 100 | From TC Agency. |

## Schedule

| ID | WBS | Task | Type | Duration | Start | Finish | Predecessors | Baseline start | Baseline finish | Baseline duration | Total slack | Free slack | Constraint | Resources | Work | Cost | Baseline cost |
| --- | --- | --- | --- | --- | --- | --- | --- | --- | --- | --- | --- | --- | --- | --- | --- | --- | --- |
| 1 | 1 | Start Book | milestone | 0d | 2005-10-31 | 2005-10-31 |  | 2005-10-31 | 2005-10-31 | 0d | 52.75d |  |  | Project Manager 1 |  |  |  |
| 2 | 2 | **Research Phase** |  | 7d | 2005-10-31 | 2005-11-08 |  | 2005-10-31 | 2005-11-08 | 7d | 1d |  |  |  | 48h | 2,720 | 2,720 |
| 3 | 2.1 | Interview Subject Matter Expert |  | 1d | 2005-10-31 | 2005-10-31 |  | 2005-10-31 | 2005-10-31 | 1d | 1d | 0d |  | Project Manager 1; Subject Matter Expert 1 | 16h | 1,280 | 1,280 |
| 4 | 2.2 | Investigate Unix |  | 4d | 2005-11-01 | 2005-11-04 | 3 | 2005-11-01 | 2005-11-04 | 4d | 1d | 0d |  | Writer 1 | 32h | 1,440 | 1,440 |
| 5 | 2.3 | Search the Web |  | 2d | 2005-11-07 | 2005-11-08 | 4 | 2005-11-07 | 2005-11-08 | 2d | 1d | 0d |  |  |  |  |  |
| 6 | 3 | **Outline Phase** |  | 10.75d | 2005-11-09 | 2005-11-23 |  | 2005-11-09 | 2005-11-23 | 10.75d | 0d |  |  |  |  |  |  |
| 7 | 3.1 | Create outline |  | 3d | 2005-11-09 | 2005-11-11 | 5 | 2005-11-09 | 2005-11-11 | 3d | 1d | 0d |  |  |  |  |  |
| 8 | 3.2 | Present to publisher |  | 1d | 2005-11-14 | 2005-11-14 | 7 | 2005-11-14 | 2005-11-14 | 1d | 1d |  |  |  |  |  |  |
| 9 | 3.3 | Review with Subject Matter Expert |  | 3d | 2005-11-15 | 2005-11-17 | 8SS | 2005-11-15 | 2005-11-17 | 3d | 0d |  | start no earlier than 2005-11-15 |  |  |  |  |
| 10 | 3.4 | Revise outline |  | 3.75d | 2005-11-18 | 2005-11-23 | 9 | 2005-11-18 | 2005-11-23 | 3.75d | 0d |  |  |  |  |  |  |
| 11 | 4 | **Development Phase** |  | 27d | 2005-11-23 | 2006-01-06 |  | 2005-11-23 | 2006-01-06 | 27d | 0d |  |  |  |  |  |  |
| 12 | 4.1 | Write content |  | 26.5d | 2005-11-23 | 2005-12-30 | 10 | 2005-11-23 | 2005-12-30 | 26.5d | 0d |  |  |  |  |  |  |
| 13 | 4.2 | Add graphics |  | 5d | 2005-12-30 | 2006-01-06 | 12 | 2005-12-30 | 2006-01-06 | 5d | 0d |  |  |  |  |  |  |
| 14 | 5 | **Edit Phase** |  | 3d | 2006-01-06 | 2006-01-11 |  | 2006-01-06 | 2006-01-11 | 3d | 0d |  |  |  |  |  |  |
| 15 | 5.1 | Check grammar, spelling, and proofread |  | 3d | 2006-01-06 | 2006-01-11 | 13 | 2006-01-06 | 2006-01-11 | 3d | 0d |  |  |  |  |  |  |
| 16 | 5.2 | Check for technical accuracy |  | 2d | 2006-01-09 | 2006-01-11 | 15FF | 2006-01-09 | 2006-01-11 | 2d | 0d |  |  |  |  |  |  |
| 17 | 6 | **Review Phase** |  | 2d | 2006-01-11 | 2006-01-13 |  | 2006-01-11 | 2006-01-13 | 2d | 0d |  |  |  |  |  |  |
| 18 | 6.1 | Approve editing changes |  | 1d | 2006-01-11 | 2006-01-12 | 16 | 2006-01-11 | 2006-01-12 | 1d | 0d |  |  |  |  |  |  |
| 19 | 6.2 | Meet with editor |  | 1d | 2006-01-12 | 2006-01-13 | 18 | 2006-01-12 | 2006-01-13 | 1d | 0d |  |  |  |  |  |  |
| 20 | 7 | **Print Phase** |  | 3d | 2006-01-13 | 2006-01-18 |  | 2006-01-13 | 2006-01-18 | 3d | 0d |  |  |  |  |  |  |
| 21 | 7.1 | Print proof |  | 1d | 2006-01-13 | 2006-01-16 | 19 | 2006-01-13 | 2006-01-16 | 1d | 0d |  |  |  |  |  |  |
| 22 | 7.2 | Review proof |  | 1d | 2006-01-16 | 2006-01-17 | 21 | 2006-01-16 | 2006-01-17 | 1d | 0d |  |  |  |  |  |  |
| 23 | 7.3 | Print final |  | 1d | 2006-01-17 | 2006-01-18 | 22 | 2006-01-17 | 2006-01-18 | 1d | 0d |  |  |  |  |  |  |
| 24 | 8 | Book Complete | milestone | 0d | 2006-01-18 | 2006-01-18 | 23 | 2006-01-18 | 2006-01-18 | 0d | 0d |  |  |  |  |  |  |

Notes:
- 7: Send the outline to Marketing.
- 13: Post the course file to the Content Management System.
- 21: Provide a hard copy proof to Project Manager.
- 24: Deliver final course.
