# Coleman Periodicals New Business

Schedule from MS Project, 2005-08-01 to 2005-09-09, costs in $, A marks actual dates.
New Periodical Division
Coleman Publishing
This plan is to launch the new magazine and newsletter division.

## Calendars

- COLEMAN: Mon-Fri 08:00-12:00, 13:00-17:00; Sat-Sun off. Exceptions (off unless hours are given): 2005-09-05.

## Resources

| Resource | Rate |
| --- | --- |
| Business advisor | 30 |
| Peers | 25 |
| Lawyer | 150 |
| Government agency | 15 |
| Manager | 20 |
| Owners | 300 |
| Accountant | 18 |
| Banker | 25 |
| Information services | 100 |

## Schedule

| ID | WBS | Task | Type | Duration | Start | Finish | Predecessors | Complete | Remaining | Baseline start | Baseline finish | Baseline duration | Total slack | Free slack | Constraint | Resources | Work | Actual work | Cost | Baseline cost | Actual cost |
| --- | --- | --- | --- | --- | --- | --- | --- | --- | --- | --- | --- | --- | --- | --- | --- | --- | --- | --- | --- | --- | --- |
| 1 | 1 | **Phase 1 - Project Initiation** |  | 29d | 2005-08-01 A | 2005-09-09 |  | 7% | 27.07d | 2005-08-01 | 2005-09-02 | 25d | 0d |  |  |  | 256h | 16h | 19,488 | 19,968 | 400 |
| 2 | 1.1 | **Self-Assessment** |  | 9d | 2005-08-01 A | 2005-08-11 |  | 50% | 4.5d | 2005-08-01 | 2005-08-05 | 5d | 0d |  |  |  | 32h | 16h | 800 | 1,280 | 400 |
| 3 | 1.1.1 | Define business vision |  | 1d | 2005-08-01 A | 2005-08-01 A |  | 100% |  | 2005-08-01 | 2005-08-02 | 2d |  |  |  | Manager | 8h | 8h | 160 | 320 | 160 |
| 4 | 1.1.2 | Identify available skills, information and support |  | 2d | 2005-08-02 A | 2005-08-10 | 3 | 50% | 1d | 2005-08-03 | 2005-08-04 | 2d | 0d |  |  | Business advisor | 16h | 8h | 480 | 800 | 240 |
| 5 | 1.1.3 | Decide whether to proceed |  | 1d | 2005-08-11 | 2005-08-11 | 4 |  |  | 2005-08-05 | 2005-08-05 | 1d | 0d |  | start no earlier than 2005-08-09 | Manager | 8h |  | 160 | 160 |  |
| 6 | 1.2 | **Define the Opportunity** |  | 10d | 2005-08-12 | 2005-08-25 |  |  |  | 2005-08-08 | 2005-08-19 | 10d | 0d |  |  |  | 96h |  | 13,408 | 13,408 |  |
| 7 | 1.2.1 | Research the market and competition |  | 1d | 2005-08-12 | 2005-08-12 | 5 |  |  | 2005-08-08 | 2005-08-08 | 1d | 0d |  |  | Business advisor | 8h |  | 240 | 240 |  |
| 8 | 1.2.2 | Interview owners of similar businesses |  | 5d | 2005-08-15 | 2005-08-19 | 7 |  |  | 2005-08-09 | 2005-08-15 | 5d | 0d |  |  | Owners | 40h |  | 12,000 | 12,000 |  |
| 9 | 1.2.3 | Identify needed resources |  | 2d | 2005-08-22 | 2005-08-23 | 8 |  |  | 2005-08-16 | 2005-08-17 | 2d | 0d |  |  | Business advisor; Peers | 32h |  | 880 | 880 |  |
| 10 | 1.2.4 | Identify operating cost elements |  | 2d | 2005-08-24 | 2005-08-25 | 9 |  |  | 2005-08-18 | 2005-08-19 | 2d | 0d |  |  | Accountant | 16h |  | 288 | 288 |  |
| 11 | 1.3 | **Evaluate Business Approach** |  | 4d | 2005-08-26 | 2005-08-31 |  |  |  | 2005-08-22 | 2005-08-25 | 4d | 0d |  |  |  | 32h |  | 640 | 640 |  |
| 12 | 1.3.1 | Define new entity requirements |  | 1d | 2005-08-26 | 2005-08-26 | 10 |  |  | 2005-08-22 | 2005-08-22 | 1d | 0d |  |  | Manager | 8h |  | 160 | 160 |  |
| 13 | 1.3.2 | Identify on-going business purchase opportunities |  | 1d | 2005-08-29 | 2005-08-29 | 12 |  |  | 2005-08-23 | 2005-08-23 | 1d | 0d |  |  | Manager | 8h |  | 160 | 160 |  |
| 14 | 1.3.3 | Research franchise possibilities |  | 1d | 2005-08-30 | 2005-08-30 | 13 |  |  | 2005-08-24 | 2005-08-24 | 1d | 0d |  |  | Manager | 8h |  | 160 | 160 |  |
| 15 | 1.3.4 | Summarize business approach |  | 1d | 2005-08-31 | 2005-08-31 | 14 |  |  | 2005-08-25 | 2005-08-25 | 1d | 0d |  |  | Manager | 8h |  | 160 | 160 |  |
| 16 | 1.4 | **Evaluate Potential Risks and Rewards** |  | 8d | 2005-08-29 | 2005-09-08 |  |  |  | 2005-08-23 | 2005-09-01 | 8d | 1d |  |  |  | 80h |  | 2,240 | 2,240 |  |
| 17 | 1.4.1 | Assess market size and stability |  | 2d | 2005-08-29 | 2005-08-30 | 12 |  |  | 2005-08-23 | 2005-08-24 | 2d | 2d | 0d |  | Business advisor | 16h |  | 480 | 480 |  |
| 18 | 1.4.2 | Estimate the competition |  | 1d | 2005-08-31 | 2005-08-31 | 17 |  |  | 2005-08-25 | 2005-08-25 | 1d | 2d | 1d |  | Business advisor | 8h |  | 240 | 240 |  |
| 19 | 1.4.3 | Assess needed resource availability |  | 2d | 2005-09-06 | 2005-09-07 | 18 |  |  | 2005-08-30 | 2005-08-31 | 2d | 1d | 0d |  | Business advisor | 16h |  | 480 | 480 |  |
| 20 | 1.4.4 | Evaluate realistic initial market share |  | 1d | 2005-09-08 | 2005-09-08 | 19 |  |  | 2005-09-01 | 2005-09-01 | 1d | 1d |  |  | Business advisor | 8h |  | 240 | 240 |  |
| 21 | 1.4.5 | Determine financial requirements |  | 2d | 2005-09-01 | 2005-09-02 | 15 |  |  | 2005-08-26 | 2005-08-29 | 2d | 0d |  |  | Business advisor | 16h |  | 480 | 480 |  |
| 22 | 1.4.6 | Review personal suitability |  | 1d | 2005-09-06 | 2005-09-06 | 21 |  |  | 2005-08-30 | 2005-08-30 | 1d | 0d |  |  | Manager | 8h |  | 160 | 160 |  |
| 23 | 1.4.7 | Evaluate initial profitability |  | 1d | 2005-09-07 | 2005-09-07 | 22 |  |  | 2005-08-31 | 2005-08-31 | 1d | 0d |  |  | Manager | 8h |  | 160 | 160 |  |
| 24 | 1.5 | Review and modify the strategic plan |  | 2d | 2005-09-08 | 2005-09-09 | 23 |  |  | 2005-09-01 | 2005-09-02 | 2d | 0d |  |  | Lawyer | 16h |  | 2,400 | 2,400 |  |
| 25 | 1.6 | Confirm decision to proceed | milestone | 0d | 2005-09-09 | 2005-09-09 | 24 |  |  | 2005-09-02 | 2005-09-02 | 0d | 0d |  |  | Manager |  |  |  |  |  |
